# KİTAP SATIŞ WEB SİTESİ

Schedule from MS Project, 2021-03-24 to 2021-04-29, costs in ₺.

## Calendars

- Standard: Mon-Fri 08:00-12:00, 13:00-17:00; Sat-Sun off.

## Resources

| Resource | Rate |
| --- | --- |
| Analist-1 | 30 |
| Analist-2 | 30 |
| Yazılımcı-1 | 50 |
| Yazılımcı-2 | 50 |
| Test Uzmanı-1 | 30 |
| Test Uzmanı-2 | 30 |
| Test Uzmanı-3 | 30 |
| Hosting Service | 1000 |

## Schedule

| ID | WBS | Task | Type | Duration | Start | Finish | Predecessors | Total slack | Constraint | Resources | Work | Cost |
| --- | --- | --- | --- | --- | --- | --- | --- | --- | --- | --- | --- | --- |
| 1 | 1 | **Analiz** |  | 6d | 2021-03-24 | 2021-03-31 |  | 0d |  |  | 72h | 2,160 |
| 2 | 1.1 | Fizibilite Çalışması |  | 4d | 2021-03-24 | 2021-03-29 |  | 0d |  | Analist-1 | 32h | 960 |
| 3 | 1.2 | Gereksinimlerin Belirlenmesi |  | 5d | 2021-03-25 | 2021-03-31 | 2SS+1d | 0d |  | Analist-2 | 40h | 1,200 |
| 4 | 1.3 | Analiz Bitimi Toplantı | milestone | 0d | 2021-03-31 | 2021-03-31 | 3 | 0d |  |  |  |  |
| 5 | 2 | **Tasarım** |  | 7d | 2021-04-01 | 2021-04-09 |  | 0d |  |  | 56h | 2,800 |
| 6 | 2.1 | Ön Tasarım |  | 3d | 2021-04-01 | 2021-04-05 | 4 | 0d |  | Yazılımcı-1 | 24h | 1,200 |
| 7 | 2.2 | Ayrıntılı Tasarım |  | 4d | 2021-04-06 | 2021-04-09 | 6 | 0d |  | Yazılımcı-2 | 32h | 1,600 |
| 8 | 2.3 | Tasarım Bitimi Toplantı | milestone | 0d | 2021-04-09 | 2021-04-09 | 7 | 0d |  |  |  |  |
| 9 | 3 | **Geliştirme&Test** |  | 14d | 2021-04-12 | 2021-04-29 |  | 0d |  |  | 272h | 11,040 |
| 10 | 3.1 | Ön Yüz Geliştirme |  | 8d | 2021-04-12 | 2021-04-21 | 8 | 0d |  | Yazılımcı-1 | 64h | 3,200 |
| 11 | 3.2 | Arka Plan Geliştirme |  | 10d | 2021-04-12 | 2021-04-23 | 8 | 0d |  | Yazılımcı-2 | 80h | 4,000 |
| 12 | 3.3 | Birim Test |  | 10d | 2021-04-12 | 2021-04-23 | 11FF, 10SS | 0d |  | Test Uzmanı-1 | 80h | 2,400 |
| 13 | 3.4 | Sistem Testi |  | 2d | 2021-04-26 | 2021-04-27 | 12 | 2d |  | Test Uzmanı-1 | 16h | 480 |
| 14 | 3.5 | Kullanıcı Testleri |  | 4d | 2021-04-26 | 2021-04-29 | 12 | 0d |  | Test Uzmanı-3 | 32h | 960 |
| 15 | 4 | Proje Teslim Toplantısı | milestone | 0d | 2021-04-29 | 2021-04-29 | 14 | 0d | finish no earlier than 2021-03-24 |  |  |  |
